# IRIS on cloud

Schedule from MS Project, 2016-12-15 to 2017-02-20.

## Calendars

- Standard: Mon-Fri 08:00-12:00, 13:00-17:00; Sat-Sun off.

## Schedule

| ID | WBS | Task | Type | Duration | Start | Finish | Predecessors | Total slack | Free slack |
| --- | --- | --- | --- | --- | --- | --- | --- | --- | --- |
| 1 | 1 | **Project Management** |  | 48d? | 2016-12-15 | 2017-02-20 |  | 0d |  |
| 2 | 1.1 | **Project Start-Up** |  | 15d | 2016-12-15 | 2017-01-04 |  | 0d |  |
| 3 | 1.1.1 | Project Charter Creation |  | 1d | 2016-12-15 | 2016-12-15 |  | 0d |  |
| 4 | 1.1.2 | Finalize the Product requirement Document |  | 1d | 2016-12-16 | 2016-12-16 | 3 | 45d | 0d |
| 5 | 1.1.3 | Prepare Project Plan |  | 1d | 2016-12-19 | 2016-12-19 | 4 | 45d |  |
| 6 | 1.1.4 | Prepare Cost Sheet |  | 1d | 2017-01-04 | 2017-01-04 | 19 | 33d |  |
| 7 | 1.2 | **Scope Finalization** |  | 12d? | 2016-12-16 | 2017-01-02 |  | 0d |  |
| 8 | 1.2.1 | Requirement Gathering |  | 1d | 2016-12-16 | 2016-12-16 | 3 | 0d |  |
| 9 | 1.2.2 | Scope Review Meeting |  | 1d | 2016-12-19 | 2016-12-19 | 8 | 0d |  |
| 10 | 1.2.3 | SRS/SOW Submission |  | 3d | 2016-12-20 | 2016-12-22 | 9 | 0d |  |
| 11 | 1.2.4 | SRS/SOW Sign Off |  | 3d | 2016-12-23 | 2016-12-27 | 10 | 0d |  |
| 12 | 1.2.5 | PIC Creation |  | 2d | 2016-12-28 | 2016-12-29 | 11 | 0d |  |
| 13 | 1.2.6 | PIC Closure |  | 1d | 2016-12-30 | 2016-12-30 | 12 | 0d |  |
| 14 | 1.2.7 | HLD Preparation |  | 1d | 2016-12-28 | 2016-12-28 | 11 | 27d | 0d |
| 15 | 1.2.8 | LLD Preparation |  | 2d | 2016-12-29 | 2016-12-30 | 14 | 27d | 0d |
| 16 | 1.2.9 | Deployment approach preparation |  | 1d? | 2017-01-02 | 2017-01-02 | 15 | 27d | 0d |
| 17 | 1.3 | **Customization** |  | 38d? | 2016-12-28 | 2017-02-17 |  | 1d |  |
| 18 | 1.3.1 | Gap Analysis |  | 2d | 2016-12-28 | 2016-12-29 | 11 | 1d | 0d |
| 19 | 1.3.2 | Effort Analysis and Approval |  | 3d | 2016-12-30 | 2017-01-03 | 18 | 1d | 0d |
| 20 | 1.3.3 | Customization based on Gap |  | 25d | 2017-01-04 | 2017-02-07 | 19 | 1d | 0d |
| 21 | 1.3.4 | Unit Testing |  | 5d | 2017-02-08 | 2017-02-14 | 20 | 1d | 0d |
| 22 | 1.3.5 | Release to PVG |  | 2d | 2017-02-15 | 2017-02-16 | 21 | 1d | 0d |
| 23 | 1.3.6 | PVG testing and Binary Release |  | 1d? | 2017-02-17 | 2017-02-17 | 22 | 1d |  |
| 24 | 1.4 | **Vendor Identification and Engagement** |  | 23d | 2016-12-23 | 2017-01-24 |  | 19d |  |
| 25 | 1.4.1 | Vendor evaluation and POC |  | 15d | 2016-12-23 | 2017-01-12 | 10 | 19d | 0d |
| 26 | 1.4.2 | Closure of Commercial Discussion with Vendor |  | 3d | 2017-01-13 | 2017-01-17 | 25 | 19d | 0d |
| 27 | 1.4.3 | Prepare PRF |  | 5d | 2017-01-18 | 2017-01-24 | 26 | 19d | 0d |
| 28 | 1.4.4 | Release Order to Supplier | milestone | 0d | 2017-01-24 | 2017-01-24 | 27 | 19d |  |

| ID | WBS | Task | Type | Duration | Start | Finish | Predecessors | Total slack | Free slack |
| --- | --- | --- | --- | --- | --- | --- | --- | --- | --- |
| 29 | 1.5 | **Staging** |  | 8d? | 2017-01-03 | 2017-01-12 |  | 27d |  |
| 30 | 1.5.1 | Prepare Staging SOW |  | 5d | 2017-01-03 | 2017-01-09 | 16 | 27d | 0d |
| 31 | 1.5.2 | Material Ready for Staging | milestone | 0d | 2017-01-09 | 2017-01-09 | 30 | 27d | 0d |
| 32 | 1.5.3 | Staging Complete |  | 2d | 2017-01-10 | 2017-01-11 | 31 | 27d | 0d |
| 33 | 1.5.4 | Staging Verification |  | 1d? | 2017-01-12 | 2017-01-12 | 32 | 27d |  |
| 34 | 1.6 | **Deployment** |  | 47d | 2016-12-15 | 2017-02-17 |  | 1d |  |
| 35 | 1.6.1 | Hardware and Software Verification as per BOM |  | 1d | 2017-02-17 | 2017-02-17 | 22, 32 | 1d |  |
| 36 | 1.6.2 | Hardware Installation | milestone | 0d | 2016-12-15 | 2016-12-15 |  | 48d |  |
| 37 | 1.6.3 | Verification of Pre Installation Checklist Details |  | 1d | 2017-01-02 | 2017-01-02 | 13 | 35d |  |
| 38 | 1.6.4 | Install Base (OS,DB etc.) Components |  | 1d | 2017-01-02 | 2017-01-02 | 13 | 29d | 0d |
| 39 | 1.6.5 | Install Application |  | 5d | 2017-01-03 | 2017-01-09 | 38 | 29d | 0d |
| 40 | 1.6.6 | Offshore Installation Support |  | 1d | 2017-01-10 | 2017-01-10 | 39 | 29d |  |
| 41 | 1.6.7 | Network Integration |  | 10d | 2017-01-02 | 2017-01-13 | 13 | 0d |  |
| 42 | 1.6.8 | Integration Testing |  | 5d | 2017-01-16 | 2017-01-20 | 41 | 0d |  |
| 43 | 1.6.9 | Ready For UAT |  | 3d | 2017-01-23 | 2017-01-25 | 42 | 0d |  |
| 44 | 1.7 | **User Acceptance** |  | 6d | 2017-01-26 | 2017-02-02 |  | 0d |  |
| 45 | 1.7.1 | Acceptance Testing |  | 5d | 2017-01-26 | 2017-02-01 | 43 | 0d |  |
| 46 | 1.7.2 | UAT Sign Off |  | 1d | 2017-02-02 | 2017-02-02 | 45 | 0d |  |
| 47 | 1.8 | **Project Closure** |  | 12d | 2017-02-03 | 2017-02-20 |  | 0d |  |
| 48 | 1.8.1 | Handover to Support |  | 10d | 2017-02-03 | 2017-02-16 | 46 | 0d |  |
| 49 | 1.8.2 | Project Closure Meeting |  | 1d | 2017-02-17 | 2017-02-17 | 48 | 0d |  |
| 50 | 1.8.3 | Project Closed |  | 1d | 2017-02-20 | 2017-02-20 | 49 | 0d |  |
| 51 | 1.8.4 | Commercial Launch of Services | milestone | 0d | 2017-02-20 | 2017-02-20 | 50, 46 | 0d |  |
